# Cronograma

Schedule from MS Project, 2009-06-01 to 2010-01-27, costs in S.

## Calendars

- Estándar: Mon-Sun 07:00-12:00, 13:00-16:00.

## Resources

| Resource | Group | Rate | Cost per use |
| --- | --- | --- | --- |
| TOPOGRAFO | Mano de Obra | 15.94 |  |
| NIVELADOR | Mano de Obra | 15.94 |  |
| OPERARIO | Mano de Obra | 12.75 |  |
| OFICIAL | Mano de Obra | 11.38 |  |
| PEON | Mano de Obra | 10.29 |  |
| CAPATAZ "B" | Mano de Obra | 15.3 |  |
| CAPATAZ "A" | Mano de Obra | 16.58 |  |
| MANO DE OBRA INC. LEYES SOCIALES | Mano de Obra | 8 |  |
| ACEITE PARA MOTOR SAE-30 | Material |  | 46.24 |
| ALAMBRE NEGRO RECOCIDO # 16 | Material |  | 2.36 |
| ALAMBRE NEGRO RECOCIDO # 8 | Material |  | 2.36 |
| CLAVOS PARA MADERA C/C 3" | Material |  | 2.42 |
| PERNOS PARA SUJECION DE GUARDAVIAS | Material |  | 37.89 |
| PLATINA DE FIERRO 1/8"X2" | Material |  | 4.91 |
| PERNO CON TUERCA Y ARANDELA 5/16" X3" | Material |  | 21.52 |
| PERNOS 3/4" x 18 C/TUERCA | Material |  | 2.69 |
| PERNOS 3/8" x 3" | Material |  | 3.08 |
| ACERO ESTRUCTURAL A-36 | Material |  | 3088.01 |
| BARRA CUADRADA 3/4" | Material |  | 3393.39 |
| PERNOS 5/16" X 6" CON TUERCA Y ARANDELA | Material |  | 3.08 |
| ACERO CORRUGADO FY=4200 KG/CM2 GRADO 60 | Material |  | 2.51 |
| FILLER | Material |  | 0.72 |
| DERECHO DE EXPLOTACION DE MATERIAL DE CANTERA | Material |  | 5 |
| DERECHO DE USO DE DME | Material |  | 2 |
| EMULSION ASFALTICA MODIFICADA CON POLIMERO SBR | Material |  | 7.13 |
| EMULSION CATIONICA DE ROTURA RAPIDA CRS-2 | Material |  | 5.88 |
| ASFALTO DILUIDO TIPO MC-30 | Material |  | 6.25 |
| CEMENTO ASFALTICO DE PENETRACION 60-70 | Material |  | 5.21 |
| CEMENTO ASFALTICO MODIFICADO CON POLIMERO SBS | Material |  | 2.4 |
| CEMENTO PORTLAND TIPO I (42.5KG) | Material |  | 17.81 |
| ADITIVO MEJORADOR DE ADHERENCIA | Material |  | 16.13 |
| CORDEL | Material |  | 0.5 |
| SOLDADURA CELLOCORD | Material |  | 13.6 |
| YESO DE 28 Kg | Material |  | 24.65 |
| SELLANTE ELASTOMERICO | Material |  | 3.84 |
| PEGAMENTO EPOXICO UNIVERSAL | Material |  | 276.51 |
| TINTA SERIGRAFICA COLOR NEGRO | Material |  | 1159.36 |
| TINTA SERIGRAFICA COLOR ROJO | Material |  | 1159.36 |
| LAMINA REFLECTIVA ALTA INTENSIDAD AMARILLA | Material |  | 7.25 |
| LAMINA REFLECTIVA ALTA INTENSIDAD BLANCA | Material |  | 7.25 |
| LAMINA REFLECTIVA ALTA INTENSIDAD VERDE | Material |  | 7.25 |
| LIJA | Material |  | 2.06 |
| GASOLINA | Material |  | 6.54 |
| ESCOBA. | Material |  | 4.83 |
| DETERGENTE | Material |  | 10.73 |
| ESCOBILLA DE ACERO | Material |  | 10 |
| TRAPO INDUSTRIAL | Material |  | 20.43 |
| MADERA TORNILLO | Material |  | 3.84 |
| CAPTAFOROS DE GUARDAVIA | Material |  | 21.4 |
| GUARDAVIAS TRANSVERSAL | Material |  | 279.76 |
| TERMINAL DE GUARDAVIAS TIPO 1 | Material |  | 101.4 |
| TERMINAL DE GUARDAVIAS TIPO 2 | Material |  | 132.41 |
| ANGULO DE ACERO 6" X 6" X 3/8" | Material |  | 41.01 |
| PLATINA DE ACERO 1/8" X 1" X 6 m | Material |  | 14.61 |
| PLATINA DE FIERRO 1 1/2"x3/16"x6m | Material |  | 33.04 |
| PLATINA DE FIERRO 1" x 3/16" x 6m | Material |  | 22.12 |
| PLATINA 3"X 3/16" | Material |  | 9.2 |
| PETROLEO | Material |  | 7.87 |
| THINER | Material |  | 20.25 |
| LUBRICANTES FILTROS Y GRASAS | Material |  |  |
| PINTURA ESMALTE SINTETICO | Material |  | 66.36 |
| PINTURA ESMALTE EPOXICO NEGRO | Material |  | 147.52 |
| PINTURA ESMALTE | Material |  | 28.89 |
| PINTURA IMPRIMANTE | Material |  | 42.97 |
| PINTURA ESMALTE EPOXICA BLANCA | Material |  | 222.04 |
| PINTURA ANTICORROSIVA | Material |  | 27.39 |
| DILUYENTE DE PINTURA ESMALTE EPOXICA | Material |  | 32.59 |
| DILUYENTE DE PINTURA ESMALTE POLIURTEANO | Material |  | 59.91 |
| DILUYENTE ANTICORROSIVO | Material |  | 39.01 |
| PINTURA ESMALTE POLIURETANO (2 Mils) | Material |  | 320.91 |
| PINTURA ESMALTE ANTICORROSIVA | Material |  | 72.95 |
| DISOLVENTE XILOL | Material |  | 19.8 |
| PINTURA DE TRAFICO | Material |  | 52.98 |
| PINTURA WASH PRIMER | Material |  | 146.41 |
| PLANCHA DE ACERO D=3/8" | Material |  | 239 |
| POSTES PARA GUARDAVIA 6"x21/4" E=6.0 mm DE 1.8M | Material |  | 101.5 |
| TUBERIA DE FIERRO NEGRO 3" | Material |  | 13.78 |
| TUBO PVC 3/8" | Material |  | 3.07 |
| TUBERIA PVC SAL 3" | Material |  | 5.22 |
| MICROESFERAS DE VIDRIO | Material |  | 3.95 |
| FIBRA DE VIDRIO DE 4 MM ACABADO | Material |  | 130.64 |
| TACHAS REFLECTORIZANTE | Material |  | 6.55 |
| MATERIALES | Material |  |  |
| MATERIALES | Material |  |  |
| ENCOFRADO METALICO | Material |  | 30 |
| SOLVENTE XILOL | Material |  | 19.8 |
| RUTEADOR | Equipo | 85 |  |
| SELLADOR | Equipo | 150 |  |
| HERRAMIENTAS MANUALES | Equipo | 8 |  |
| EQUIPO DE SOLDAR | Equipo | 4.14 |  |
| MEZCLADOR DE CONCRETO 20-35 HP 16 P3 | Equipo | 29.11 |  |
| CAMION CISTERNA 4X2 (ASFALTO) | Equipo | 152.58 |  |
| MOTOBOMBA 7-10 HP 3-4" | Equipo | 5.96 |  |
| VOLQUETE 15 M3 | Equipo | 220.76 |  |
| CAMION CISTERNA 4X2 (AGUA) 2 000GLN | Equipo | 128.62 |  |
| MAQUINA PARA PINTAR MARCAS EN PAVIMENTO | Equipo | 45 |  |
| EQUIPO DE PINTURA | Equipo | 49.26 |  |
| COMPRESORA NEUMATICA 250-330 PCM 87 HP | Equipo | 63.52 |  |
| BARREDORA MECANICA 10-20 HP | Equipo | 39.69 |  |
| COMPACTADOR VIBR. TIPO PLANCHA 7 HP | Equipo | 22.17 |  |
| RODILLO LISO VIBR AUTOP 101-135HP 10-12T | Equipo | 137.08 |  |
| RODILLO LISO VIBR MANUAL 10.8HP 0.8-1.1T | Equipo | 27.69 |  |
| RODILLO NEUMATICO AUTOP 81-100HP 5.5-20T | Equipo | 117.88 |  |
| RODILLO TANDEM ESTATIC AUT 58-70HP 8-10T | Equipo | 54.49 |  |
| RETROEXCAVADOR SOBRE ORUGA 80-110HP 0.5-1.3 Y | Equipo | 144.86 |  |
| TRACTOR DE ORUGAS DE 190-240 HP | Equipo | 327.38 |  |
| CARGADOR S/LLANTAS 125 - 155 HP 3 YD3. | Equipo | 160.1 |  |
| CARGADOR S/LLANTAS 100-115 HP 2-2.35 YD3 | Equipo | 137.31 |  |
| ESPARCIDORA DE AGREGADOS | Equipo | 150 |  |
| FRESADORA DE PAVIMENTOS | Equipo | 813.72 |  |
| CORTADORA DE ASFALTO | Equipo | 79.25 |  |
| MARTILLO NEUMATICO DE 25 - 29 Kg. | Equipo | 4.53 |  |
| VIBRADOR DE CONCRETO 4 HP 2.4" | Equipo | 4.88 |  |
| ZARANDA VIBRATORIA 4"x6"x14" M.E. 15 HP | Equipo | 48.66 |  |
| TRACTOR DE TIRO DE 80 HP | Equipo | 62.56 |  |
| CHANCADORA PRIMARIA SECUNDARIA 5 FAJAS 75 HP 46-70 Ton/h | Equipo | 152.2 |  |
| MOTONIVELADORA DE 125 HP | Equipo | 149.3 |  |
| CAMIONETA PICK UP 4x2 84 HP | Equipo | 40.12 |  |
| CAMION IMPRIMADOR 210 HP 2 000 GLN | Equipo | 108.66 |  |
| GRUPO ELECTROGENO 116 HP 75 KW | Equipo | 95.1 |  |
| GRUPO ELECTROGENO 230 HP 150 KW | Equipo | 121.26 |  |
| SECADOR ARIDOS 2-M.E. 70HP 60-115 TON/H | Equipo | 45.7 |  |
| PAVIMENTADORA SOBRE ORUGAS | Equipo | 128.09 |  |
| PLANTA DE ASFALTO EN CALIENTE 150 TON/H | Equipo | 334.81 |  |
| CALENTADOR DE ACEITE 48 - S | Equipo | 21.7 |  |
| CAMION BARANDA 3 TON | Equipo | 63.4 |  |
| FAJA TRANSPORT 18"X50" M.E. 3HP 150 TON/H | Equipo | 6.52 |  |
| TEODOLITO | Equipo | 9.62 |  |
| NIVEL | Equipo | 7.77 |  |
| MAQUINARIA Y EQUIPO NACIONAL | Equipo | 8 |  |
| TRASLADO DE EQUIPO Y HERRAMIENTAS | Equipo | 8 |  |

## Schedule

| ID | WBS | Task | Duration | Start | Finish | Predecessors | Total slack | Free slack | Constraint | Resources | Work | Cost | Text1 | Text8 | Text3 | Text4 | Text2 | Text6 |
| --- | --- | --- | --- | --- | --- | --- | --- | --- | --- | --- | --- | --- | --- | --- | --- | --- | --- | --- |
| 1 | 1 | **MANTENIMIENTO PERIODICO DE LA CARRETERA PONTON QDA SECA. - PTE. SANTA** | 240d | 2009-06-01 | 2010-01-27 |  | 0d |  |  |  | 1666666667h | 554,834,621.38 |  |  |  |  |  |  |
| 2 | 1.1 | **PRELIMINARES** | 239d | 2009-06-01 | 2010-01-26 |  | 0d |  |  |  | 9983.24h | 146,494.22 | 01 | 000000000000099 |  |  |  |  |
| 3 | 1.1.1 | MOVILIZACION Y DESMOVILIZACION DE EQUIPO | 60d | 2009-06-01 | 2010-01-26 |  | 0d |  | start no earlier than 2009-06-01 |  |  |  | 01.01 | 000000000000100 | 460726.56 | 460726.56 |  |  |
| 4 | 1.1.2 | TOPOGRAFIA Y GEOREFERENCIACION | 119d | 2009-06-11 | 2009-10-08 | 3SS+10d | 0d |  | start no earlier than 2009-06-01 | CEMENTO PORTLAND TIPO I (42.5KG) [11814%]; YESO DE 28 Kg [590.7%]; PINTURA ESMALTE [5907%]; TOPOGRAFO [99.3%]; NIVELADOR [99.3%]; PEON [595.7%]; CAPATAZ "B" [19.9%]; TEODOLITO [99.3%]; NIVEL [99.3%]; CLAVOS PARA MADERA C/C 3" [118.1%]; ACERO CORRUGADO FY=4200 KG/CM2 GRADO 60 [35442%]; CORDEL [2362.8%]; MADERA TORNILLO [318978%] | 9640.22h | 124,919.07 | 01.02 | 000000000000101 | 1080.58 | 127659.72 | 118.14 |  |
| 5 | 1.1.3 | MANTENIMIENTO DE TRANSITO Y SEGURIDAD VIAL | 229d | 2009-06-11 | 2010-01-26 | 4SS | 1d | 0d | start no earlier than 2009-06-01 |  |  |  | 01.03 | 000000000000102 | 350344.76 | 350344.76 |  |  |
| 6 | 1.1.4 | ACCESOS A CANTERAS, BOTADEROS Y FUENTES DE AGUA | 3d | 2009-06-11 | 2009-06-14 | 5SS | 227d |  | start no earlier than 2009-06-01 | GASOLINA [915.6%]; PEON [573.3%]; CAPATAZ "B" [72.7%]; MOTOBOMBA 7-10 HP 3-4" [282.6%]; CAMION CISTERNA 4X2 (AGUA) 2 000GLN [282.6%]; RODILLO LISO VIBR AUTOP 101-135HP 10-12T [72.7%]; TRACTOR DE ORUGAS DE 190-240 HP [72.7%]; MOTONIVELADORA DE 125 HP [72.7%] | 343.01h | 21,575.15 | 01.04 | 000000000000200 | 9897.76 | 21577.12 | 2.18 |  |
| 7 | 1.2 | **MOVIMIENTO DE TIERRAS** | 41d | 2009-06-21 | 2009-08-01 |  | 0d |  |  |  | 1834.46h | 77,357.16 | 02 | 000000000000103 |  |  |  |  |
| 8 | 1.2.1 | REMOCION DE CARPETA ASFALTICA EXISTENTE | 4d | 2009-06-21 | 2009-06-25 | 4SS+10d | 0d |  | start no earlier than 2009-06-01 | OPERARIO [199.7%]; OFICIAL; PEON [399.5%]; CAPATAZ "B" [20%]; COMPRESORA NEUMATICA 250-330 PCM 87 HP [49.9%]; CARGADOR S/LLANTAS 100-115 HP 2-2.35 YD3; MARTILLO NEUMATICO DE 25 - 29 Kg. | 310h | 8,139.88 | 02.01 | 000000000000104 | 8.23 | 8219.38 | 998.71 | 250 |
| 9 | 1.2.2 | REMOCION BASE Y SUB BASE EXISTENTE | 30d | 2009-06-25 | 2009-07-25 | 8 | 0d |  | start no earlier than 2009-06-01 | OFICIAL; PEON [199.7%]; CAPATAZ "B" [10%]; RETROEXCAVADOR SOBRE ORUGA 80-110HP 0.5-1.3 Y | 982.73h | 42,748.85 | 02.02 | 000000000000105 | 7.17 | 42964.58 | 5992.27 | 200 |
| 10 | 1.2.3 | ESCARIFICADO Y CONFORMACION DE SUB RASANTE | 7d | 2009-07-25 | 2009-08-01 | 9 | 179d |  | start no earlier than 2009-06-01 | GASOLINA [862.9%]; PEON [471%]; CAPATAZ "B" [89.3%]; MOTOBOMBA 7-10 HP 3-4" [114.2%]; CAMION CISTERNA 4X2 (AGUA) 2 000GLN [114.2%]; RODILLO LISO VIBR AUTOP 101-135HP 10-12T [89.3%]; MOTONIVELADORA DE 125 HP [89.3%] | 541.73h | 26,468.42 | 02.03 | 000000000000106 | 8.87 | 26575.76 | 2996.14 | 480 |
| 11 | 1.2.4 | ESCARIFICADO Y CONFORMACION DE BASE EXISTENTE | 2d | 2009-07-06 | 2009-07-08 | 12 | 65d |  |  |  |  |  |  |  |  |  |  |  |
| 12 | 1.2.5 | DEMOLICION DE PAVIMENTO DE CONCRETO EXISTENTE | 11d | 2009-06-25 | 2009-07-06 | 8 | 65d |  |  |  |  |  |  |  |  |  |  |  |
| 13 | 1.3 | **SUB BASES Y BASES** | 43d | 2009-08-14 | 2009-09-26 |  | 0d |  |  |  | 14108.6h | 795,421.87 | 03 | 000000000000107 |  |  |  |  |
| 14 | 1.3.1 | SUB-BASE GRANULAR | 20d | 2009-08-14 | 2009-09-03 | 103 | 0d |  | start no earlier than 2009-06-01 | GASOLINA [1797.7%]; PETROLEO [101869%]; FAJA TRANSPORT 18"X50" M.E. 3HP 150 TON/H [187.3%]; OPERARIO [187.3%]; OFICIAL [131.7%]; PEON [1315.7%]; CAPATAZ "B" [37.5%]; CAPATAZ "A" [30.3%]; MOTOBOMBA 7-10 HP 3-4" [166.5%]; CAMION CISTERNA 4X2 (AGUA) 2 000GLN [166.5%]; RODILLO LISO VIBR AUTOP 101-135HP 10-12T [94.3%]; TRACTOR DE ORUGAS DE 190-240 HP [104.9%]; CARGADOR S/LLANTAS 125 - 155 HP 3 YD3. [74.9%]; CARGADOR S/LLANTAS 100-115 HP 2-2.35 YD3 [37.5%]; ZARANDA VIBRATORIA 4"x6"x14" M.E. 15 HP [187.3%]; MOTONIVELADORA DE 125 HP [94.3%]; GRUPO ELECTROGENO 116 HP 75 KW [187.3%]; DERECHO DE EXPLOTACION DE MATERIAL DE CANTERA [599227%] | 4804.7h | 274,102.2 | 03.01 | 000000000000108 | 31.35 | 156548.11 | 4993.56 | 530 |
| 15 | 1.3.2 | BASE GRANULAR | 23d | 2009-09-03 | 2009-09-26 | 14, 11 | 0d |  | start no earlier than 2009-06-01 | GASOLINA [2157.2%]; PETROLEO [194150%]; FAJA TRANSPORT 18"X50" M.E. 3HP 150 TON/H [204.3%]; OPERARIO [482.1%]; OFICIAL [133.4%]; PEON [2136.6%]; CAPATAZ "B" [40.9%]; CAPATAZ "A" [170.9%]; MOTOBOMBA 7-10 HP 3-4" [181.6%]; CAMION CISTERNA 4X2 (AGUA) 2 000GLN [181.6%]; RODILLO LISO VIBR AUTOP 101-135HP 10-12T [92.5%]; TRACTOR DE ORUGAS DE 190-240 HP [114.4%]; CARGADOR S/LLANTAS 125 - 155 HP 3 YD3. [81.7%]; CARGADOR S/LLANTAS 100-115 HP 2-2.35 YD3 [179.8%]; ZARANDA VIBRATORIA 4"x6"x14" M.E. 15 HP [204.3%]; CHANCADORA PRIMARIA SECUNDARIA 5 FAJAS 75 HP 46-70 Ton/h [277.8%]; MOTONIVELADORA DE 125 HP [92.5%]; GRUPO ELECTROGENO 116 HP 75 KW [482.1%]; DERECHO DE EXPLOTACION DE MATERIAL DE CANTERA [599227%] | 9303.88h | 521,319.67 | 03.02 | 000000000000109 | 54.84 | 273846.83 | 4993.56 | 490 |
| 16 | 1.4 | **PAVIMENTO ASFALTICO** | 204d | 2009-06-21 | 2010-01-11 |  | 7d |  |  |  | 1666666667h | 16,447,960.77 | 04 | 000000000000110 |  |  |  |  |
| 17 | 1.4.1 | IMPRIMACION ASFALTICA | 7d | 2009-09-26 | 2009-10-03 | 15 | 0d |  | start no earlier than 2009-06-01 | PETROLEO [339.6%]; FAJA TRANSPORT 18"X50" M.E. 3HP 150 TON/H [2.7%]; OPERARIO [2.7%]; OFICIAL [95.9%]; PEON [565.5%]; CAPATAZ "B" [0.3%]; CAPATAZ "A" [93.8%]; VOLQUETE 15 M3 [10%]; BARREDORA MECANICA 10-20 HP [93.6%]; TRACTOR DE ORUGAS DE 190-240 HP [0.9%]; CARGADOR S/LLANTAS 125 - 155 HP 3 YD3. [0.6%]; CARGADOR S/LLANTAS 100-115 HP 2-2.35 YD3 [3.4%]; ZARANDA VIBRATORIA 4"x6"x14" M.E. 15 HP [2.7%]; TRACTOR DE TIRO DE 80 HP [93.6%]; CAMION IMPRIMADOR 210 HP 2 000 GLN [93.6%]; GRUPO ELECTROGENO 116 HP 75 KW [2.7%]; DERECHO DE EXPLOTACION DE MATERIAL DE CANTERA [1997.4%] | 594.8h | 17,886.8 | 04.01 | 000000000000111 | 0.5 | 9987.12 | 19974.23 | 5400 |
| 18 | 1.4.2 | RIEGO DE LIGA | 109d | 2009-08-22 | 2009-12-09 | 20, 21, 22, 35, 34, 36 | 7d | 0d | start no earlier than 2009-06-01 | OFICIAL [101%]; PEON [598.9%]; CAPATAZ "A" [101%]; BARREDORA MECANICA 10-20 HP [101%]; TRACTOR DE TIRO DE 80 HP [101%]; CAMION IMPRIMADOR 210 HP 2 000 GLN [101%] | 9626.65h | 264,150.95 | 04.02 | 000000000000112 | 0.43 | 516284.59 | 1200661.83 | 5800 |
| 19 | 1.4.3 | TRATAMIENTO SUPERFICIAL SIMPLE | 89d | 2009-08-27 | 2009-11-24 | 18SS+5d | 7d |  | start no earlier than 2009-06-01 | PETROLEO [225866%]; FAJA TRANSPORT 18"X50" M.E. 3HP 150 TON/H [29.7%]; OPERARIO [70.1%]; OFICIAL [105%]; PEON [878.5%]; CAPATAZ "B" [10%]; CAPATAZ "A" [52.8%]; BARREDORA MECANICA 10-20 HP [99%]; RODILLO NEUMATICO AUTOP 81-100HP 5.5-20T [99%]; TRACTOR DE ORUGAS DE 190-240 HP [16.6%]; CARGADOR S/LLANTAS 125 - 155 HP 3 YD3. [11.9%]; CARGADOR S/LLANTAS 100-115 HP 2-2.35 YD3 [26.1%]; ESPARCIDORA DE AGREGADOS [99%]; ZARANDA VIBRATORIA 4"x6"x14" M.E. 15 HP [29.7%]; TRACTOR DE TIRO DE 80 HP [99%]; CHANCADORA PRIMARIA SECUNDARIA 5 FAJAS 75 HP 46-70 Ton/h [40.4%]; CAMION IMPRIMADOR 210 HP 2 000 GLN [99%]; GRUPO ELECTROGENO 116 HP 75 KW [29.7%]; GRUPO ELECTROGENO 230 HP 150 KW [40.4%]; DERECHO DE EXPLOTACION DE MATERIAL DE CANTERA [697116%] | 13072.8h | 665,080.29 | 04.03 | 000000000000197 | 1.91 | 665745.78 | 348558 | 4000 |
| 20 | 1.4.4 | BACHEO SUPERFICIAL | 51d | 2009-06-21 | 2009-08-11 | 8SS | 7d | 0d | start no earlier than 2009-06-01 | GASOLINA [655.1%]; PETROLEO [323294%]; FAJA TRANSPORT 18"X50" M.E. 3HP 150 TON/H [14.1%]; OPERARIO [70.8%]; OFICIAL [53.6%]; PEON [950.9%]; CAPATAZ "B" [29.6%]; CAPATAZ "A" [18.8%]; CAMION CISTERNA 4X2 (ASFALTO) [23.7%]; MOTOBOMBA 7-10 HP 3-4" [11.9%]; CAMION CISTERNA 4X2 (AGUA) 2 000GLN [11.9%]; COMPRESORA NEUMATICA 250-330 PCM 87 HP [8.9%]; COMPACTADOR VIBR. TIPO PLANCHA 7 HP [25.8%]; RODILLO LISO VIBR MANUAL 10.8HP 0.8-1.1T [79.3%]; TRACTOR DE ORUGAS DE 190-240 HP [6.4%]; CARGADOR S/LLANTAS 125 - 155 HP 3 YD3. [4.6%]; CARGADOR S/LLANTAS 100-115 HP 2-2.35 YD3 [17.6%]; CORTADORA DE ASFALTO [8.9%]; MARTILLO NEUMATICO DE 25 - 29 Kg. [17.8%]; ZARANDA VIBRATORIA 4"x6"x14" M.E. 15 HP [14.1%]; CHANCADORA PRIMARIA SECUNDARIA 5 FAJAS 75 HP 46-70 Ton/h [21.6%]; GRUPO ELECTROGENO 116 HP 75 KW [20.1%]; GRUPO ELECTROGENO 230 HP 150 KW [19.7%]; SECADOR ARIDOS 2-M.E. 70HP 60-115 TON/H [4.2%]; PLANTA DE ASFALTO EN CALIENTE 150 TON/H [4.2%]; CALENTADOR DE ACEITE 48 - S [4.2%]; DERECHO DE EXPLOTACION DE MATERIAL DE CANTERA [174376%]; ESCOBA. [1374.8%] | 5886.15h | 184,003.06 | 04.04 | 000000000000208 | 18.41 | 186102.64 | 10108.78 | 200 |
| 21 | 1.4.5 | BACHEO PROFUNDO | 4d | 2009-06-21 | 2009-06-25 | 20SS | 58d | 0d | start no earlier than 2009-06-01 | GASOLINA [45.9%]; PETROLEO [4849.4%]; FAJA TRANSPORT 18"X50" M.E. 3HP 150 TON/H [4.7%]; OPERARIO [15%]; OFICIAL [10.3%]; PEON [986.1%]; CAPATAZ "B" [41.7%]; CAPATAZ "A" [10.7%]; CAMION CISTERNA 4X2 (ASFALTO) [3.8%]; MOTOBOMBA 7-10 HP 3-4" [10.6%]; CAMION CISTERNA 4X2 (AGUA) 2 000GLN [10.6%]; COMPRESORA NEUMATICA 250-330 PCM 87 HP [0.6%]; COMPACTADOR VIBR. TIPO PLANCHA 7 HP [47.1%]; RODILLO LISO VIBR MANUAL 10.8HP 0.8-1.1T [12.5%]; TRACTOR DE ORUGAS DE 190-240 HP [2.4%]; CARGADOR S/LLANTAS 125 - 155 HP 3 YD3. [1.7%]; CARGADOR S/LLANTAS 100-115 HP 2-2.35 YD3 [6.1%]; MARTILLO NEUMATICO DE 25 - 29 Kg. [1.1%]; ZARANDA VIBRATORIA 4"x6"x14" M.E. 15 HP [4.7%]; CHANCADORA PRIMARIA SECUNDARIA 5 FAJAS 75 HP 46-70 Ton/h [6.7%]; GRUPO ELECTROGENO 116 HP 75 KW [9%]; GRUPO ELECTROGENO 230 HP 150 KW [3.1%]; SECADOR ARIDOS 2-M.E. 70HP 60-115 TON/H [0.7%]; PLANTA DE ASFALTO EN CALIENTE 150 TON/H [0.7%]; CALENTADOR DE ACEITE 48 - S [0.7%]; DERECHO DE EXPLOTACION DE MATERIAL DE CANTERA [4782.4%]; ESCOBA. [17.5%] | 380.97h | 6,829.13 | 04.05 | 000000000000209 | 55.53 | 6942.92 | 125.03 | 40 |
| 22 | 1.4.6 | BACHEO EN BERMAS | 62d | 2009-06-21 | 2009-08-22 | 20SS | 7d | 0d | start no earlier than 2009-06-01 | EMULSION CATIONICA DE ROTURA RAPIDA CRS-2; GASOLINA [7947.4%]; PETROLEO [79473.9%]; FAJA TRANSPORT 18"X50" M.E. 3HP 150 TON/H [3%]; OPERARIO [47%]; OFICIAL [98%]; PEON [1401.7%]; CAPATAZ "B" [50.9%]; CAPATAZ "A" [35.8%]; CAMION CISTERNA 4X2 (ASFALTO) [39%]; MOTOBOMBA 7-10 HP 3-4" [24%]; CAMION CISTERNA 4X2 (AGUA) 2 000GLN [24%]; COMPRESORA NEUMATICA 250-330 PCM 87 HP [39.9%]; COMPACTADOR VIBR. TIPO PLANCHA 7 HP [17.2%]; RODILLO LISO VIBR MANUAL 10.8HP 0.8-1.1T [20%]; TRACTOR DE ORUGAS DE 190-240 HP [1.7%]; CARGADOR S/LLANTAS 125 - 155 HP 3 YD3. [1.2%]; CARGADOR S/LLANTAS 100-115 HP 2-2.35 YD3 [2.6%]; CORTADORA DE ASFALTO [39.9%]; MARTILLO NEUMATICO DE 25 - 29 Kg. [39.9%]; ZARANDA VIBRATORIA 4"x6"x14" M.E. 15 HP [3%]; CHANCADORA PRIMARIA SECUNDARIA 5 FAJAS 75 HP 46-70 Ton/h [4.1%]; CAMION IMPRIMADOR 210 HP 2 000 GLN [20%]; GRUPO ELECTROGENO 116 HP 75 KW [3%]; GRUPO ELECTROGENO 230 HP 150 KW [4.1%]; DERECHO DE EXPLOTACION DE MATERIAL DE CANTERA [245290%]; ESCOBA. [13245.7%] | 9523h | 512,725.5 | 04.06 | 000000000000210 | 10.41 | 1276733.1 | 122644.87 | 400 |
| 23 | 1.4.7 | FRESADO e = 6 cm. | 83d | 2009-06-21 | 2009-09-12 | 20SS | 4d | 0d | start no earlier than 2009-06-01 | PEON [200.1%]; CAPATAZ "A" [9%]; BARREDORA MECANICA 10-20 HP [98.9%]; FRESADORA DE PAVIMENTOS [98.9%]; TRACTOR DE TIRO DE 80 HP [98.9%] | 3359.59h | 616,445.42 | 04.07 | 000000000000115 | 4.13 | 1218484.84 | 295032.65 | 1800 |
| 24 | 1.4.8 | FRESADO e = 3 cm. | 55d | 2009-09-12 | 2009-11-06 | 23 | 4d | 0d | start no earlier than 2009-06-01 | PEON [197%]; CAPATAZ "A" [10.6%]; BARREDORA MECANICA 10-20 HP [98.5%]; FRESADORA DE PAVIMENTOS [98.5%]; TRACTOR DE TIRO DE 80 HP [98.5%] | 2213.88h | 406,681.62 | 04.08 | 000000000000204 | 3.48 | 629980.29 | 181028.82 | 2150 |
| 25 | 1.4.9 | PAVIMENTO DE CONCRETO ASFALTICO CALIENTE (MAC) | 1d | 2009-09-12 | 2009-09-13 | 18SS+5d, 23 | 146d |  | start no earlier than 2009-06-01 | PETROLEO [85847.2%]; FAJA TRANSPORT 18"X50" M.E. 3HP 150 TON/H [138.4%]; OPERARIO [544.2%]; OFICIAL [263.2%]; PEON [2205.5%]; CAPATAZ "B" [56.9%]; CAPATAZ "A" [29.6%]; RODILLO NEUMATICO AUTOP 81-100HP 5.5-20T [60.8%]; RODILLO TANDEM ESTATIC AUT 58-70HP 8-10T [60.8%]; TRACTOR DE ORUGAS DE 190-240 HP [56.3%]; CARGADOR S/LLANTAS 125 - 155 HP 3 YD3. [40.2%]; CARGADOR S/LLANTAS 100-115 HP 2-2.35 YD3 [196.7%]; ZARANDA VIBRATORIA 4"x6"x14" M.E. 15 HP [138.4%]; CHANCADORA PRIMARIA SECUNDARIA 5 FAJAS 75 HP 46-70 Ton/h [223.5%]; GRUPO ELECTROGENO 116 HP 75 KW [138.4%]; GRUPO ELECTROGENO 230 HP 150 KW [284.3%]; SECADOR ARIDOS 2-M.E. 70HP 60-115 TON/H [60.8%]; PAVIMENTADORA SOBRE ORUGAS [60.8%]; PLANTA DE ASFALTO EN CALIENTE 150 TON/H [60.8%]; CALENTADOR DE ACEITE 48 - S [60.8%]; DERECHO DE EXPLOTACION DE MATERIAL DE CANTERA [32152.5%] | 374.41h | 25,791.94 | 04.09 | 000000000000118 | 101.37 | 26074.39 | 257.22 | 423 |
| 26 | 1.4.10 | PAVIMENTO DE CONCRETO ASFALTICO CALIENTE CON POLIMERO SBS | 100d | 2009-10-03 | 2010-01-11 | 18SS+30d, 19SS+30d, 23, 24SS+10d, 17 | 0d |  | start no earlier than 2009-06-01 | PETROLEO; FAJA TRANSPORT 18"X50" M.E. 3HP 150 TON/H [226.4%]; OPERARIO [890.4%]; OFICIAL [430.6%]; PEON [3608.6%]; CAPATAZ "B" [93%]; CAPATAZ "A" [48.4%]; RODILLO NEUMATICO AUTOP 81-100HP 5.5-20T [99.4%]; RODILLO TANDEM ESTATIC AUT 58-70HP 8-10T [99.4%]; TRACTOR DE ORUGAS DE 190-240 HP [92.1%]; CARGADOR S/LLANTAS 125 - 155 HP 3 YD3. [65.8%]; CARGADOR S/LLANTAS 100-115 HP 2-2.35 YD3 [321.9%]; ZARANDA VIBRATORIA 4"x6"x14" M.E. 15 HP [226.4%]; CHANCADORA PRIMARIA SECUNDARIA 5 FAJAS 75 HP 46-70 Ton/h [365.8%]; GRUPO ELECTROGENO 116 HP 75 KW [226.4%]; GRUPO ELECTROGENO 230 HP 150 KW [465.2%]; SECADOR ARIDOS 2-M.E. 70HP 60-115 TON/H [99.4%]; PAVIMENTADORA SOBRE ORUGAS [99.4%]; PLANTA DE ASFALTO EN CALIENTE 150 TON/H [99.4%]; CALENTADOR DE ACEITE 48 - S [99.4%]; DERECHO DE EXPLOTACION DE MATERIAL DE CANTERA | 61258.7h | 4,083,116.39 | 04.10 | 000000000000119 | 101.37 | 3839566.15 | 37876.75 | 423 |
| 27 | 1.4.11 | CEMENTO ASFALTICO DE PENETRACION 60 - 70 | 52d | 2009-06-21 | 2009-09-11 | 20SS, 21SS | 137.88d |  | start no earlier than 2009-06-01 | CEMENTO ASFALTICO DE PENETRACION 60-70 | 16313611h | 204,312.29 | 04.11 | 000000000000120 | 5.21 | 204312.29 | 39215.41 |  |
| 28 | 1.4.12 | CEMENTO ASFALTICO MODIFICADO CON POLIMEROS SBS | 100d | 2009-10-03 | 2010-01-11 | 26SS | 16d |  | start no earlier than 2009-06-01 | CEMENTO ASFALTICO MODIFICADO CON POLIMERO SBS | 1666666667h | 5,000,000 | 04.12 | 000000000000121 | 2.4 | 13590178.82 | 5662574.51 |  |
| 29 | 1.4.13 | EMULSION ASFALTICA DE ROTURA RAPIDA CRS-2 | 90d | 2009-08-22 | 2009-11-20 | 18SS | 68d |  | start no earlier than 2009-06-01 | EMULSION CATIONICA DE ROTURA RAPIDA CRS-2 | 155834201h | 1,272,645.97 | 04.13 | 000000000000199 | 5.88 | 1272645.97 | 216436.39 |  |
| 30 | 1.4.14 | EMULSION ASFALTICA MODIFICADA CON POLIMERO SBR | 68d | 2009-09-16 | 2009-11-23 | 18SS+25d | 65d |  | start no earlier than 2009-06-01 | EMULSION ASFALTICA MODIFICADA CON POLIMERO SBR | 87600891h | 1,148,151.39 | 04.14 | 000000000000205 | 7.13 | 1148151.39 | 161031.05 |  |
| 31 | 1.4.15 | ASFALTO DILUIDO TIPO MC-30 | 59d | 2009-06-21 | 2009-09-02 | 20SS | 147d |  | start no earlier than 2009-06-01 | ASFALTO DILUIDO TIPO MC-30 [844838%] | 3987635h | 52,802.37 | 04.15 | 000000000000124 | 6.25 | 52802.38 | 8448.38 |  |
| 32 | 1.4.16 | FILLER MINERAL (CAL HIDRATADA) | 151d | 2009-06-21 | 2010-01-03 | 20SS | 33.88d |  | start no earlier than 2009-06-01 | FILLER | 1663940680h | 1,287,401.1 | 04.16 | 000000000000126 | 0.72 | 1287401.1 | 1788057.08 |  |
| 33 | 1.4.17 | ADITIVO MEJORADOR DE ADHERENCIA | 151d | 2009-06-21 | 2010-01-03 | 20SS | 33.88d |  | start no earlier than 2009-06-01 | ADITIVO MEJORADOR DE ADHERENCIA | 35123035h | 468,985.56 | 04.17 | 000000000000127 | 16.13 | 468985.56 | 29075.36 |  |
| 34 | 1.4.18 | TRATAMIENTO DE FISURAS < 3MM | 8d | 2009-06-21 | 2009-06-29 | 20SS | 30d | 0d | start no earlier than 2009-06-01 | OPERARIO [90.8%]; OFICIAL [183.3%]; PEON [364.8%]; CAPATAZ "A" [8.6%]; COMPRESORA NEUMATICA 250-330 PCM 87 HP [90.8%]; CAMION BARANDA 3 TON [90.8%] | 530.58h | 11,943.32 | 04.18 | 000000000000128 | 1.11 | 12168.22 | 10962.36 | 1500 |
| 35 | 1.4.19 | TRATAMIENTO DE FISURAS >3MM Y <6MM | 32d | 2009-06-21 | 2009-07-23 | 34SS | 30d |  | start no earlier than 2009-06-01 | OPERARIO [400.2%]; OFICIAL [299.8%]; PEON [798.8%]; CAPATAZ "A" [10.5%]; RUTEADOR; SELLADOR; COMPRESORA NEUMATICA 250-330 PCM 87 HP; TRACTOR DE TIRO DE 80 HP; CAMION BARANDA 3 TON | 5149.02h | 152,402.7 | 04.19 | 000000000000129 | 4.01 | 153856.72 | 38368.26 | 1200 |
| 36 | 1.4.20 | TRATAMIENTO DE FISURAS >6MM | 7d | 2009-06-21 | 2009-06-28 | 34SS | 55d |  | start no earlier than 2009-06-01 | OPERARIO [391.5%]; OFICIAL [293.6%]; PEON [783%]; CAPATAZ "A" [9.8%]; SELLADOR [97.9%]; COMPRESORA NEUMATICA 250-330 PCM 87 HP [97.9%]; TRACTOR DE TIRO DE 80 HP [97.9%]; CAMION BARANDA 3 TON [97.9%] | 1046.91h | 27,877.17 | 04.20 | 000000000000130 | 5.14 | 28173.27 | 5481.18 | 800 |
| 37 | 1.4.21 | SELLANTE ELASTOMERICO | 32d | 2009-06-21 | 2009-07-23 | 34SS | 188d |  | start no earlier than 2009-06-01 | SELLANTE ELASTOMERICO | 2581855h | 38,727.82 | 04.21 | 000000000000131 | 3.84 | 38727.82 | 10085.37 |  |

| ID | WBS | Task | Duration | Start | Finish | Predecessors | Total slack | Free slack | Constraint | Resources | Work | Cost | Text1 | Text8 | Text2 | Text3 | Text4 | Text6 |
| --- | --- | --- | --- | --- | --- | --- | --- | --- | --- | --- | --- | --- | --- | --- | --- | --- | --- | --- |
| 38 | 1.5 | **OBRAS DE ARTE Y DRENAJE** | 80d | 2009-08-11 | 2009-10-30 |  | 89d |  |  |  | 829375h | 8,736,949.58 | 05 | 000000000000132 |  |  |  |  |
| 39 | 1.5.1 | ROCE Y LIMPIEZA | 79d | 2009-08-11 | 2009-10-29 | 20 | 89d | 0d | start no earlier than 2009-06-01 | PEON [124899%]; CAPATAZ "B" [6326.9%] | 829345h | 8,734,292.98 | 05.01 | 000000000000133 | 187465 | 0.61 | 114353.65 | 300 |
| 40 | 1.5.2 | REPOSICION DE JUNTA DE DILATACION | 1d | 2009-10-29 | 2009-10-30 | 39 | 89d |  | start no earlier than 2009-06-01 | CEMENTO PORTLAND TIPO I (42.5KG) [1768%]; ACEITE PARA MOTOR SAE-30 [17.7%]; GASOLINA [89.3%]; PETROLEO [69.2%]; FAJA TRANSPORT 18"X50" M.E. 3HP 150 TON/H [1.1%]; OPERARIO [56.7%]; OFICIAL [45.5%]; PEON [167.2%]; CAPATAZ "B" [2.6%]; CAPATAZ "A" [3.3%]; MEZCLADOR DE CONCRETO 20-35 HP 16 P3 [13.8%]; MOTOBOMBA 7-10 HP 3-4" [0.9%]; VOLQUETE 15 M3 [10.9%]; CAMION CISTERNA 4X2 (AGUA) 2 000GLN [0.9%]; COMPRESORA NEUMATICA 250-330 PCM 87 HP [22.1%]; TRACTOR DE ORUGAS DE 190-240 HP [0.4%]; CARGADOR S/LLANTAS 125 - 155 HP 3 YD3. [0.3%]; CARGADOR S/LLANTAS 100-115 HP 2-2.35 YD3 [5.1%]; MARTILLO NEUMATICO DE 25 - 29 Kg. [22.1%]; VIBRADOR DE CONCRETO 4 HP 2.4" [13.8%]; ZARANDA VIBRATORIA 4"x6"x14" M.E. 15 HP [1.1%]; CHANCADORA PRIMARIA SECUNDARIA 5 FAJAS 75 HP 46-70 Ton/h [1.7%]; GRUPO ELECTROGENO 116 HP 75 KW [1.1%]; GRUPO ELECTROGENO 230 HP 150 KW [1.7%]; SELLANTE ELASTOMERICO [3952.5%]; ANGULO DE ACERO 6" X 6" X 3/8" [1700%]; PLANCHA DE ACERO D=3/8" [238%]; DERECHO DE EXPLOTACION DE MATERIAL DE CANTERA [256.4%]; ACERO ESTRUCTURAL A-36 [2.5%]; BARRA CUADRADA 3/4" [2.5%] | 29.78h | 2,656.6 | 05.02 | 000000000000134 | 8.5 | 313.41 | 2663.99 | 200 |
| 41 | 1.6 | **TRANSPORTE** | 204d | 2009-06-21 | 2010-01-11 |  | 16d |  |  |  | 2391208h | 527,474,921.45 | 06 | 000000000000135 |  |  |  |  |
| 42 | 1.6.1 | TRANSPORTE DE MATERIAL GRANULAR MENOR A 1KM. | 155d | 2009-06-21 | 2009-11-23 | 20SS | 59d | 0d | start no earlier than 2009-06-01 | OFICIAL [49.6%]; VOLQUETE 15 M3 [99.1%]; CARGADOR S/LLANTAS 100-115 HP 2-2.35 YD3 [49.6%] | 2458.72h | 362,790.14 | 06.01 | 000000000000201 | 25957.15 | 6.5 | 168721.48 | 363 |
| 43 | 1.6.2 | TRANSPORTE DE MATERIAL GRANULAR MAYOR A 1KM. | 155d | 2009-06-21 | 2009-11-23 | 42SS | 59d | 0d | start no earlier than 2009-06-01 | VOLQUETE 15 M3 [45356.9%] | 562426h | 124,161,063.2 | 06.02 | 000000000000137 | 697798.44 | 1.15 | 802468.21 | 1538 |
| 44 | 1.6.3 | TRANSPORTE DE MEZCLA ASFALTICA MENOR A 1KM. | 100d | 2009-10-03 | 2010-01-11 | 26SS | 16d | 0d | start no earlier than 2009-06-01 | OFICIAL [49.2%]; VOLQUETE 15 M3 [99%] | 1186.06h | 179,403.05 | 06.03 | 000000000000202 | 38870.81 | 3.6 | 139934.92 | 504 |
| 45 | 1.6.4 | TRANSPORTE DE MEZCLA ASFALTICA MAYOR A 1KM. | 100d | 2009-10-03 | 2010-01-11 | 44SS | 16d |  | start no earlier than 2009-06-01 | VOLQUETE 15 M3 [92153.3%] | 737226h | 162,750,064.74 | 06.04 | 000000000000139 | 1134194.21 | 1.43 | 1621897.72 | 1236 |
| 46 | 1.6.5 | TRANSPORTE DE MATERIAL EXCEDENTE MENOR A 1 KM | 125d | 2009-06-21 | 2009-10-24 | 20SS | 47d | 0d | start no earlier than 2009-06-01 | OFICIAL [49.7%]; VOLQUETE 15 M3 [99.5%]; CARGADOR S/LLANTAS 100-115 HP 2-2.35 YD3 [49.7%] | 1989.71h | 293,586.53 | 06.05 | 000000000000203 | 52835.97 | 7.02 | 370908.51 | 336 |
| 47 | 1.6.6 | TRANSPORTE DE MATERIAL EXCEDENTE MAYOR A 1 KM | 125d | 2009-06-21 | 2009-10-24 | 46SS | 47d | 0d | start no earlier than 2009-06-01 | VOLQUETE 15 M3 [108592%] | 1085921h | 239,728,013.78 | 06.06 | 000000000000141 | 1378947.84 | 1.39 | 1916737.5 | 1260 |
| 48 | 1.7 | **SEÑALIZACION Y SEGURIDAD VIAL** | 169d | 2009-08-11 | 2010-01-27 |  | 0d |  |  |  | 15077.3h | 982,221.26 | 07 | 000000000000142 |  |  |  |  |
| 49 | 1.7.1 | **SEÑAL PREVENTIVA** | 98d | 2009-08-11 | 2009-11-17 |  | 50d |  |  |  | 302.64h | 11,348.69 | 07.01 | 000000000000143 |  |  |  |  |
| 50 | 1.7.1.1 | PANEL SEÑAL PREVENTIVA FIBRA DE VIDRIO 0.90 m. x 0.90 m. | 1d | 2009-11-13 | 2009-11-14 | 63 | 78d | 0d | start no earlier than 2009-06-01 | TINTA SERIGRAFICA COLOR NEGRO [0.5%]; THINER [2.7%]; PINTURA ESMALTE [2%]; PINTURA IMPRIMANTE [2%]; OPERARIO [40.4%]; OFICIAL [6.7%]; PEON [13.6%]; CAPATAZ "B" [5.4%]; EQUIPO DE SOLDAR [3.4%]; CAMION BARANDA 3 TON [6.8%]; PERNOS 5/16" X 6" CON TUERCA Y ARANDELA [139.4%]; SOLDADURA CELLOCORD [7%]; FIBRA DE VIDRIO DE 4 MM ACABADO [116.5%]; LAMINA REFLECTIVA ALTA INTENSIDAD AMARILLA [1573.9%]; PLATINA DE ACERO 1/8" X 1" X 6 m [420.1%]; PLATINA DE FIERRO 1" x 3/16" x 6m [960%] | 6.11h | 654.3 | 07.01.01 | 000000000000206 | 16 | 274.24 | 4387.84 | 20 |
| 51 | 1.7.1.2 | PANEL SEÑAL PREVENTIVA FIBRA DE VIDRIO 0.75 m. x 0.75 m. | 3d | 2009-11-14 | 2009-11-17 | 50 | 78d | 0d | start no earlier than 2009-06-01 | TINTA SERIGRAFICA COLOR NEGRO [11.6%]; THINER [57.9%]; PINTURA ESMALTE [43.4%]; PINTURA IMPRIMANTE [43.4%]; OPERARIO [289.7%]; OFICIAL [48.3%]; PEON [96.7%]; CAPATAZ "B" [38.7%]; EQUIPO DE SOLDAR [24.2%]; CAMION BARANDA 3 TON [48.4%]; PERNOS 5/16" X 6" CON TUERCA Y ARANDELA [2902.8%]; SOLDADURA CELLOCORD [144%]; FIBRA DE VIDRIO DE 4 MM ACABADO [1647.6%]; LAMINA REFLECTIVA ALTA INTENSIDAD AMARILLA [17572.7%]; PLATINA DE ACERO 1/8" X 1" X 6 m [1410.1%]; PLATINA DE FIERRO 1" x 3/16" x 6m [2300%] | 131.07h | 6,588.24 | 07.01.02 | 000000000000207 | 46 | 219.37 | 10091.02 | 20 |
| 52 | 1.7.1.3 | MANTENIMIENTO DE POSTES DE CONCRETO (PINTADO) | 4d | 2009-08-11 | 2009-08-15 | 20 | 51d | 0d | start no earlier than 2009-06-01 | PINTURA ESMALTE [764%]; DISOLVENTE XILOL [95.5%]; OFICIAL [95.5%]; PEON [95.5%]; CAPATAZ "B" [19.1%]; CAMIONETA PICK UP 4x2 84 HP [47.8%]; DETERGENTE [4775%]; TRAPO INDUSTRIAL [477.5%] | 82.51h | 2,218.32 | 07.01.03 | 000000000000145 | 191 | 11.74 | 2242.34 | 50 |
| 53 | 1.7.1.4 | MANTENIMIENTO DE PANEL DE SEÑAL PREVENTIVA | 4d | 2009-08-15 | 2009-08-19 | 52 | 51d | 0d | start no earlier than 2009-06-01 | OFICIAL [81%]; PEON [81%]; CAPATAZ "B" [16.2%]; CAMIONETA PICK UP 4x2 84 HP [81%]; DETERGENTE [1620%]; TRAPO INDUSTRIAL [162%] | 82.94h | 1,887.83 | 07.01.04 | 000000000000146 | 162 | 11.77 | 1906.74 | 50 |
| 54 | 1.7.2 | **SEÑAL REGLAMENTARIA** | 93d | 2009-08-19 | 2009-11-20 |  | 50d |  |  |  | 375.43h | 15,430.64 | 07.02 | 000000000000147 |  |  |  |  |
| 55 | 1.7.2.1 | PANEL SEÑAL REGLAMENTARIA FIBRA DE VIDRIO | 3d | 2009-11-17 | 2009-11-20 | 51 | 78d |  | start no earlier than 2009-06-01 | PINTURA ESMALTE SINTETICO [136.8%]; TINTA SERIGRAFICA COLOR NEGRO [3.6%]; TINTA SERIGRAFICA COLOR ROJO [10.8%]; THINER [54%]; OPERARIO [480%]; OFICIAL [60%]; PEON [120%]; CAPATAZ "B" [60%]; EQUIPO DE SOLDAR [40%]; CAMION BARANDA 3 TON [60%]; PERNOS 5/16" X 6" CON TUERCA Y ARANDELA [3600%]; FIBRA DE VIDRIO DE 4 MM ACABADO [3456%]; PLATINA DE FIERRO 1/8"X2" [7200%]; LAMINA REFLECTIVA ALTA INTENSIDAD BLANCA [37188%]; PLATINA DE FIERRO 1" x 3/16" x 6m [2400.1%] | 196.8h | 11,577.07 | 07.02.01 | 000000000000148 | 36 | 323.36 | 11640.96 | 15 |
| 56 | 1.7.2.2 | MANTENIMIENTO DE POSTES DE CONCRETO (PINTADO) | 4d | 2009-08-19 | 2009-08-23 | 53 | 51d | 0d | start no earlier than 2009-06-01 | PINTURA ESMALTE [604%]; DISOLVENTE XILOL [75.5%]; OFICIAL [75.5%]; PEON [75.5%]; CAPATAZ "B" [15.1%]; CAMIONETA PICK UP 4x2 84 HP [37.8%]; DETERGENTE [3775%]; TRAPO INDUSTRIAL [377.5%] | 65.23h | 1,753.75 | 07.02.02 | 000000000000149 | 151 | 11.74 | 1772.74 | 50 |
| 57 | 1.7.2.3 | MANTENIMIENTO DE PANEL DE SEÑAL REGLAMENTARIA | 4d | 2009-08-23 | 2009-08-27 | 56 | 51d | 0d | start no earlier than 2009-06-01 | OFICIAL [84.4%]; PEON [168.8%]; CAPATAZ "B" [16.9%]; CAMIONETA PICK UP 4x2 84 HP [84.4%]; DETERGENTE [405%]; TRAPO INDUSTRIAL [135%] | 113.4h | 2,099.82 | 07.02.03 | 000000000000150 | 135 | 15.76 | 2127.6 | 40 |
| 58 | 1.7.3 | **SEÑALES INFORMATIVAS** | 80d | 2009-08-27 | 2009-11-15 |  | 50d |  |  |  | 1848.46h | 93,104.32 | 07.03 | 000000000000151 |  |  |  |  |
| 59 | 1.7.3.1 | PANEL DE SEÑAL INFORMATIVA (FIBRA DE VIDRIO) | 8d | 2009-11-07 | 2009-11-15 | 64 | 78d | 0d | start no earlier than 2009-06-01 | PINTURA ESMALTE SINTETICO [394.2%]; THINER [31.5%]; OPERARIO [730%]; CAPATAZ "B" [73%]; EQUIPO DE SOLDAR [45.6%]; PERNO CON TUERCA Y ARANDELA 5/16" X3" [9723.6%]; SOLDADURA CELLOCORD [876%]; PLANCHA DE ACERO D=3/8" [102.5%]; FIBRA DE VIDRIO DE 4 MM ACABADO [4467.6%]; LAMINA REFLECTIVA ALTA INTENSIDAD BLANCA [23454.9%]; LAMINA REFLECTIVA ALTA INTENSIDAD VERDE [46909.8%]; PLATINA DE FIERRO 1 1/2"x3/16"x6m [1752%] | 543.12h | 21,033.91 | 07.03.01 | 000000000000152 | 43.8 | 484.79 | 21233.8 |  |
| 60 | 1.7.3.2 | MANTENIMIENTO DE PANEL DE SEÑAL INFORMATIVAS | 5d | 2009-08-27 | 2009-09-01 | 57 | 51d | 0d | start no earlier than 2009-06-01 | OFICIAL [94.8%]; PEON [189.5%]; CAPATAZ "B" [18.9%]; CAMIONETA PICK UP 4x2 84 HP [94.8%]; DETERGENTE [568.5%]; TRAPO INDUSTRIAL [189.5%] | 159.18h | 2,947.52 | 07.03.02 | 000000000000153 | 189.5 | 15.76 | 2986.52 | 40 |
| 61 | 1.7.3.3 | MANTENIMIENTO DE ESTRUCTURAS METALICAS | 8d | 2009-09-01 | 2009-09-09 | 60 | 50d | 0d | start no earlier than 2009-06-01 | DILUYENTE DE PINTURA ESMALTE EPOXICA [576.6%]; THINER [662.8%]; PINTURA ESMALTE EPOXICO NEGRO [288.3%]; PINTURA ESMALTE [1110.2%]; PINTURA ESMALTE EPOXICA BLANCA [2883.2%]; PINTURA ANTICORROSIVA [1110.2%]; PINTURA DE TRAFICO [576.6%]; OPERARIO [202.7%]; OFICIAL [335.9%]; PEON [558%]; CAPATAZ "B" [44.3%]; VOLQUETE 15 M3 [228.7%]; EQUIPO DE PINTURA [197.3%]; COMPRESORA NEUMATICA 250-330 PCM 87 HP [104.1%]; CARGADOR S/LLANTAS 100-115 HP 2-2.35 YD3 [114.4%]; MARTILLO NEUMATICO DE 25 - 29 Kg. [5.4%] | 1146.15h | 69,122.89 | 07.03.03 | 000000000000154 | 165.7 | 372.29 | 61688.45 | 24 |

| ID | WBS | Task | Duration | Start | Finish | Predecessors | Total slack | Free slack | Constraint | Resources | Work | Cost | Text1 | Text8 | Text2 | Text3 | Text4 | Text6 |
| --- | --- | --- | --- | --- | --- | --- | --- | --- | --- | --- | --- | --- | --- | --- | --- | --- | --- | --- |
| 62 | 1.7.4 | **ELEMENTOS DE SOPORTE DE SEÑALES** | 7d | 2009-11-06 | 2009-11-13 |  | 28d |  |  |  | 434.3h | 10,672.84 | 07.04 | 000000000000155 |  |  |  |  |
| 63 | 1.7.4.1 | POSTE DE SOPORTE DE SEÑALES | 7d | 2009-11-06 | 2009-11-13 | 24 | 38d | 0d | start no earlier than 2009-06-01 | CEMENTO PORTLAND TIPO I (42.5KG) [6183.8%]; ENCOFRADO METALICO [5100%]; ACEITE PARA MOTOR SAE-30 [68.3%]; GASOLINA [309.7%]; PETROLEO [230.7%]; THINER [96.9%]; PINTURA ESMALTE [204%]; PINTURA IMPRIMANTE [204%]; FAJA TRANSPORT 18"X50" M.E. 3HP 150 TON/H [0.5%]; OPERARIO [29%]; OFICIAL [215%]; PEON [355.3%]; CAPATAZ "B" [49.3%]; CAPATAZ "A" [6.5%]; MEZCLADOR DE CONCRETO 20-35 HP 16 P3 [6.4%]; MOTOBOMBA 7-10 HP 3-4" [0.5%]; VOLQUETE 15 M3 [5.4%]; CAMION CISTERNA 4X2 (AGUA) 2 000GLN [0.5%]; TRACTOR DE ORUGAS DE 190-240 HP [0.2%]; CARGADOR S/LLANTAS 125 - 155 HP 3 YD3. [0.2%]; CARGADOR S/LLANTAS 100-115 HP 2-2.35 YD3 [2.4%]; VIBRADOR DE CONCRETO 4 HP 2.4" [9.7%]; ZARANDA VIBRATORIA 4"x6"x14" M.E. 15 HP [0.5%]; CHANCADORA PRIMARIA SECUNDARIA 5 FAJAS 75 HP 46-70 Ton/h [0.8%]; GRUPO ELECTROGENO 116 HP 75 KW [0.5%]; GRUPO ELECTROGENO 230 HP 150 KW [0.8%]; ALAMBRE NEGRO RECOCIDO # 8 [2040%]; ACERO CORRUGADO FY=4200 KG/CM2 GRADO 60 [21420%]; TUBO PVC 3/8" [1530%]; DERECHO DE EXPLOTACION DE MATERIAL DE CANTERA [1045.5%] | 382.67h | 8,892.2 | 07.04.01 | 000000000000156 | 51 | 176.87 | 9020.37 |  |
| 64 | 1.7.4.2 | ESTRUCTURA DE SOPORTE DE SEÑALES | 1d | 2009-11-06 | 2009-11-07 | 63SS | 44d | 0d | start no earlier than 2009-06-01 | CEMENTO PORTLAND TIPO I (42.5KG) [1794.4%]; ACEITE PARA MOTOR SAE-30 [20.1%]; GASOLINA [87.2%]; PETROLEO [67.8%]; THINER [14%]; PINTURA ESMALTE [3%]; PINTURA ANTICORROSIVA [3%]; FAJA TRANSPORT 18"X50" M.E. 3HP 150 TON/H [1%]; OPERARIO [130.3%]; OFICIAL [88.1%]; PEON [336.3%]; CAPATAZ "B" [17%]; CAPATAZ "A" [13%]; EQUIPO DE SOLDAR [12.5%]; MEZCLADOR DE CONCRETO 20-35 HP 16 P3 [13%]; MOTOBOMBA 7-10 HP 3-4" [1%]; VOLQUETE 15 M3 [6.6%]; CAMION CISTERNA 4X2 (AGUA) 2 000GLN [1%]; TRACTOR DE ORUGAS DE 190-240 HP [0.4%]; CARGADOR S/LLANTAS 125 - 155 HP 3 YD3. [0.4%]; CARGADOR S/LLANTAS 100-115 HP 2-2.35 YD3 [2.5%]; VIBRADOR DE CONCRETO 4 HP 2.4" [17%]; ZARANDA VIBRATORIA 4"x6"x14" M.E. 15 HP [1%]; CHANCADORA PRIMARIA SECUNDARIA 5 FAJAS 75 HP 46-70 Ton/h [1.6%]; GRUPO ELECTROGENO 116 HP 75 KW [1%]; GRUPO ELECTROGENO 230 HP 150 KW [1.6%]; ALAMBRE NEGRO RECOCIDO # 16 [130%]; ALAMBRE NEGRO RECOCIDO # 8 [177%]; CLAVOS PARA MADERA C/C 3" [130%]; ACERO CORRUGADO FY=4200 KG/CM2 GRADO 60 [1858.5%]; SOLDADURA CELLOCORD [400%]; PLANCHA DE ACERO D=3/8" [14%]; DERECHO DE EXPLOTACION DE MATERIAL DE CANTERA [328%]; PLATINA 3"X 3/16" [180%]; TUBERIA DE FIERRO NEGRO 3" [1480%]; MADERA TORNILLO [4225%]; PERNOS 3/4" x 18 C/TUERCA [1600%]; PERNOS 3/8" x 3" [2000%]; LIJA [20%] | 51.62h | 1,780.64 | 07.04.02 | 000000000000157 |  | 898.59 | 1797.18 |  |
| 65 | 1.7.5 | **POSTES DELINEADORES** | 73d | 2009-09-09 | 2009-11-21 |  | 28d |  |  |  | 2539.69h | 44,012.92 | 07.05 | 000000000000158 |  |  |  |  |
| 66 | 1.7.5.1 | MANTENIMIENTO DE POSTES DELINEADORES DE CONCRETO | 6d | 2009-09-09 | 2009-09-15 | 61 | 50d | 0d | start no earlier than 2009-06-01 | THINER [365%]; PINTURA ESMALTE [730%]; OFICIAL [97.3%]; PEON [194.7%]; CAPATAZ "B" [19.5%]; LAMINA REFLECTIVA ALTA INTENSIDAD BLANCA [3536.1%]; LIJA [29200%] | 149.5h | 2,778.83 | 07.05.01 | 000000000000159 | 146 | 19.38 | 2829.48 | 25 |
| 67 | 1.7.5.2 | POSTES DELINEADOR DE CONCRETO | 5d | 2009-11-13 | 2009-11-18 | 63, 64 | 38d | 0d | start no earlier than 2009-06-01 | CEMENTO PORTLAND TIPO I (42.5KG) [5267.5%]; ENCOFRADO METALICO [8600%]; ACEITE PARA MOTOR SAE-30 [60.2%]; GASOLINA [244.1%]; PETROLEO [203.2%]; THINER [215%]; PINTURA ESMALTE EPOXICA BLANCA [430%]; FAJA TRANSPORT 18"X50" M.E. 3HP 150 TON/H [0.6%]; OPERARIO [119.8%]; OFICIAL [126.8%]; PEON [164.8%]; CAPATAZ "B" [21.1%]; CAPATAZ "A" [7.6%]; MEZCLADOR DE CONCRETO 20-35 HP 16 P3 [7.5%]; MOTOBOMBA 7-10 HP 3-4" [0.6%]; VOLQUETE 15 M3 [4.3%]; CAMION CISTERNA 4X2 (AGUA) 2 000GLN [0.6%]; TRACTOR DE ORUGAS DE 190-240 HP [0.3%]; CARGADOR S/LLANTAS 125 - 155 HP 3 YD3. [0.3%]; CARGADOR S/LLANTAS 100-115 HP 2-2.35 YD3 [1.6%]; VIBRADOR DE CONCRETO 4 HP 2.4" [7.5%]; ZARANDA VIBRATORIA 4"x6"x14" M.E. 15 HP [0.6%]; CHANCADORA PRIMARIA SECUNDARIA 5 FAJAS 75 HP 46-70 Ton/h [1%]; GRUPO ELECTROGENO 116 HP 75 KW [0.6%]; GRUPO ELECTROGENO 230 HP 150 KW [1%]; ALAMBRE NEGRO RECOCIDO # 8 [2150%]; ACERO CORRUGADO FY=4200 KG/CM2 GRADO 60 [22575%]; DERECHO DE EXPLOTACION DE MATERIAL DE CANTERA [1075%]; LAMINA REFLECTIVA ALTA INTENSIDAD BLANCA [2838%] | 186.57h | 8,292.76 | 07.05.02 | 000000000000160 | 86 | 97.19 | 8358.34 | 20 |
| 68 | 1.7.5.3 | MANTENIMIENTO DE POSTES DELINEADOR DE TUBO DE PVC D=3" | 26d | 2009-09-15 | 2009-10-11 | 66 | 50d | 0d | start no earlier than 2009-06-01 | DISOLVENTE XILOL [647%]; OPERARIO [199.1%]; OFICIAL [199.1%]; PEON [597.2%]; CAPATAZ "B" [19.9%]; DETERGENTE [32350%]; LAMINA REFLECTIVA ALTA INTENSIDAD BLANCA [31340.7%]; ESCOBILLA DE ACERO [6470%] | 2111.81h | 29,926.4 | 07.05.03 | 000000000000161 | 1294 | 23.67 | 30628.98 | 50 |
| 69 | 1.7.5.4 | POSTES DELINEADOR DE TUBO PVC D=3" | 3d | 2009-11-18 | 2009-11-21 | 67 | 38d | 0d | start no earlier than 2009-06-01 | CEMENTO PORTLAND TIPO I (42.5KG) [3001.2%]; ACEITE PARA MOTOR SAE-30 [34.3%]; GASOLINA [139.1%]; PETROLEO [115.8%]; THINER [122.5%]; PINTURA ESMALTE EPOXICA BLANCA [245%]; FAJA TRANSPORT 18"X50" M.E. 3HP 150 TON/H [0.6%]; OPERARIO [97.5%]; OFICIAL [104%]; PEON [140.1%]; CAPATAZ "B" [8.6%]; CAPATAZ "A" [7.2%]; MEZCLADOR DE CONCRETO 20-35 HP 16 P3 [7.1%]; MOTOBOMBA 7-10 HP 3-4" [0.6%]; VOLQUETE 15 M3 [4.1%]; CAMION CISTERNA 4X2 (AGUA) 2 000GLN [0.6%]; TRACTOR DE ORUGAS DE 190-240 HP [0.2%]; CARGADOR S/LLANTAS 125 - 155 HP 3 YD3. [0.3%]; CARGADOR S/LLANTAS 100-115 HP 2-2.35 YD3 [1.5%]; VIBRADOR DE CONCRETO 4 HP 2.4" [7.1%]; ZARANDA VIBRATORIA 4"x6"x14" M.E. 15 HP [0.6%]; CHANCADORA PRIMARIA SECUNDARIA 5 FAJAS 75 HP 46-70 Ton/h [0.9%]; GRUPO ELECTROGENO 116 HP 75 KW [0.6%]; GRUPO ELECTROGENO 230 HP 150 KW [0.9%]; TUBERIA PVC SAL 3" [5145%]; DERECHO DE EXPLOTACION DE MATERIAL DE CANTERA [612.5%]; LAMINA REFLECTIVA ALTA INTENSIDAD BLANCA [1893.8%] | 91.8h | 3,014.93 | 07.05.04 | 000000000000162 | 49 | 62.15 | 3045.35 | 20 |
| 70 | 1.7.6 | TACHA RETROREFLECTIVA | 6d | 2010-01-21 | 2010-01-27 | 72 | 0d |  | start no earlier than 2009-06-01 | PEGAMENTO EPOXICO UNIVERSAL [5373%]; OPERARIO [198.9%]; OFICIAL; PEON [198.9%]; CAPATAZ "B" [19.8%]; CAMIONETA PICK UP 4x2 84 HP; TACHAS REFLECTORIZANTE [358200%] | 296.05h | 43,126.33 | 07.06 | 000000000000163 | 3582 | 13.43 | 48106.26 | 300 |
| 71 | 1.7.7 | **SEÑALIZACION HORIZONTAL** | 76d | 2009-11-06 | 2010-01-21 |  | 6d |  |  |  | 6604.97h | 593,944.15 | 07.07 | 000000000000164 |  |  |  |  |
| 72 | 1.7.7.1 | MARCAS EN EL PAVIMENTO | 17d | 2010-01-04 | 2010-01-21 | 26FS-7d | 0d |  | start no earlier than 2009-06-01 | DISOLVENTE XILOL [31678%]; PINTURA DE TRAFICO [442700%]; OPERARIO [198%]; OFICIAL [297%]; PEON [594%]; CAPATAZ "B" [19.8%]; MAQUINA PARA PINTAR MARCAS EN PAVIMENTO [99%]; CAMION BARANDA 3 TON [99%]; MICROESFERAS DE VIDRIO | 1777.14h | 326,906.2 | 07.07.01 | 000000000000165 | 39597.54 | 9.83 | 389243.82 | 800 |
| 73 | 1.7.7.2 | CONSTRUCCION DE REDUCIDORES DE VELOCIDAD. | 8d | 2009-11-06 | 2009-11-14 | 24 | 81d | 0d | start no earlier than 2009-06-01 | CEMENTO PORTLAND TIPO I (42.5KG) [212890%]; ACEITE PARA MOTOR SAE-30 [1548.3%]; GASOLINA [7899.9%]; PETROLEO [6061.6%]; FAJA TRANSPORT 18"X50" M.E. 3HP 150 TON/H [11.5%]; OPERARIO [811.7%]; OFICIAL [822.7%]; PEON [2489.1%]; CAPATAZ "B" [51.7%]; CAPATAZ "A" [165.2%]; MEZCLADOR DE CONCRETO 20-35 HP 16 P3 [151.2%]; MOTOBOMBA 7-10 HP 3-4" [18.3%]; VOLQUETE 15 M3 [91.5%]; CAMION CISTERNA 4X2 (AGUA) 2 000GLN [18.3%]; COMPRESORA NEUMATICA 250-330 PCM 87 HP [120%]; COMPACTADOR VIBR. TIPO PLANCHA 7 HP [130%]; TRACTOR DE ORUGAS DE 190-240 HP [4.9%]; CARGADOR S/LLANTAS 125 - 155 HP 3 YD3. [3.5%]; CARGADOR S/LLANTAS 100-115 HP 2-2.35 YD3 [42.2%]; MARTILLO NEUMATICO DE 25 - 29 Kg. [120%]; VIBRADOR DE CONCRETO 4 HP 2.4" [302.4%]; ZARANDA VIBRATORIA 4"x6"x14" M.E. 15 HP [11.5%]; CHANCADORA PRIMARIA SECUNDARIA 5 FAJAS 75 HP 46-70 Ton/h [18.2%]; GRUPO ELECTROGENO 116 HP 75 KW [11.5%]; GRUPO ELECTROGENO 230 HP 150 KW [18.2%]; ALAMBRE NEGRO RECOCIDO # 16 [1077.1%]; ALAMBRE NEGRO RECOCIDO # 8 [33280%]; CLAVOS PARA MADERA C/C 3" [1077.1%]; ACERO CORRUGADO FY=4200 KG/CM2 GRADO 60 [349440%]; DERECHO DE EXPLOTACION DE MATERIAL DE CANTERA [22450.2%]; MADERA TORNILLO [35006.4%] | 3464.72h | 117,684.61 | 07.07.02 | 000000000000167 | 16 | 7418.63 | 118698.08 |  |
| 74 | 1.7.7.3 | RESONADOR DE 7.20X5.00X0.25 DE CONCRETO ARMADO | 3d | 2009-11-14 | 2009-11-17 | 73 | 81d |  | start no earlier than 2009-06-01 | CEMENTO PORTLAND TIPO I (42.5KG) [43200%]; ACEITE PARA MOTOR SAE-30 [432%]; GASOLINA [2183.3%]; PETROLEO [1691.3%]; FAJA TRANSPORT 18"X50" M.E. 3HP 150 TON/H [8.5%]; OPERARIO [1162.3%]; OFICIAL [1284.7%]; PEON [2480.8%]; CAPATAZ "B" [114.2%]; CAPATAZ "A" [23.2%]; MEZCLADOR DE CONCRETO 20-35 HP 16 P3 [112.5%]; MOTOBOMBA 7-10 HP 3-4" [7.2%]; VOLQUETE 15 M3 [89.1%]; CAMION CISTERNA 4X2 (AGUA) 2 000GLN [7.2%]; COMPRESORA NEUMATICA 250-330 PCM 87 HP [0.7%]; TRACTOR DE ORUGAS DE 190-240 HP [3.7%]; CARGADOR S/LLANTAS 125 - 155 HP 3 YD3. [2.6%]; CARGADOR S/LLANTAS 100-115 HP 2-2.35 YD3 [43.4%]; MARTILLO NEUMATICO DE 25 - 29 Kg. [1.4%]; VIBRADOR DE CONCRETO 4 HP 2.4" [112.5%]; ZARANDA VIBRATORIA 4"x6"x14" M.E. 15 HP [8.5%]; CHANCADORA PRIMARIA SECUNDARIA 5 FAJAS 75 HP 46-70 Ton/h [13.5%]; GRUPO ELECTROGENO 116 HP 75 KW [8.5%]; GRUPO ELECTROGENO 230 HP 150 KW [13.5%]; ALAMBRE NEGRO RECOCIDO # 16 [4320%]; ALAMBRE NEGRO RECOCIDO # 8 [34680%]; CLAVOS PARA MADERA C/C 3" [4320%]; ACERO CORRUGADO FY=4200 KG/CM2 GRADO 60 [364140%]; DERECHO DE EXPLOTACION DE MATERIAL DE CANTERA [6264%]; MADERA TORNILLO [140400%] | 1319.57h | 46,638.9 | 07.07.03 | 000000000000166 |  | 7850.94 | 47105.64 | 2.5 |
| 75 | 1.7.7.4 | PINTADO DE REDUCIDORES DE VELOCIDAD | 2d | 2009-11-14 | 2009-11-16 | 73 | 82d |  | start no earlier than 2009-06-01 | DILUYENTE DE PINTURA ESMALTE POLIURTEANO [18144%]; DILUYENTE ANTICORROSIVO [18144%]; PINTURA ESMALTE POLIURETANO (2 Mils) [25920%]; OPERARIO [64.8%]; PEON [64.8%]; CAPATAZ "B" [13%]; COMPRESORA NEUMATICA 250-330 PCM 87 HP [64.8%]; CAMION BARANDA 3 TON [64.8%] | 43.55h | 102,714.43 | 07.07.04 | 000000000000168 | 1036.8 | 99.08 | 102726.14 | 800 |
| 76 | 1.7.8 | **GUARDAVIA METALICA** | 79d | 2009-10-11 | 2009-12-29 |  | 28d |  |  |  | 1739.45h | 129,909.73 | 07.08 | 000000000000169 |  |  |  |  |
| 77 | 1.7.8.1 | MANTENIMIENTO DE GUARDAVIAS | 10d | 2009-10-11 | 2009-10-21 | 68 | 50d | 0d | start no earlier than 2009-06-01 | THINER [356.5%]; PINTURA ESMALTE EPOXICO NEGRO [713%]; PINTURA ESMALTE EPOXICA BLANCA [2495.5%]; PINTURA DE TRAFICO [713%]; PEON [190.1%]; CAPATAZ "B" [19%]; CAMIONETA PICK UP 4x2 84 HP [95.1%]; DETERGENTE [7130%]; LIJA [7130%] | 243.35h | 12,804.2 | 07.08.01 | 000000000000170 | 713 | 18.04 | 12862.52 | 75 |
| 78 | 1.7.8.2 | TERMINAL DE GUARDAVIAS TIPO 1 | 2d | 2009-12-25 | 2009-12-27 | 84 | 38d | 0d | start no earlier than 2009-06-01 | PINTURA ESMALTE [46.2%]; PINTURA DE TRAFICO [30.8%]; PINTURA WASH PRIMER [42%]; SOLVENTE XILOL [7.3%]; OPERARIO [56%]; CAPATAZ "B" [11.2%]; PERNOS PARA SUJECION DE GUARDAVIAS [2800%]; TERMINAL DE GUARDAVIAS TIPO 1 [2800%] | 10.75h | 4,134.38 | 07.08.02 | 000000000000171 | 28 | 147.81 | 4138.68 | 25 |
| 79 | 1.7.8.3 | MANTENIMIENTO DE TERMINAL TIPO T1 (PINTADO) | 1d | 2009-10-21 | 2009-10-22 | 77 | 50d | 0d | start no earlier than 2009-06-01 | THINER [12.5%]; PINTURA ESMALTE EPOXICA BLANCA [50%]; PINTURA DE TRAFICO [50%]; PEON [66.7%]; CAPATAZ "B" [6.7%]; CAMIONETA PICK UP 4x2 84 HP [33.3%]; DETERGENTE [250%]; LIJA [250%] | 8.53h | 342.06 | 07.08.03 | 000000000000172 | 25 | 13.76 | 344 | 75 |
| 80 | 1.7.8.4 | TERMINAL DE GUARDAVIAS TIPO 2 | 2d | 2009-12-27 | 2009-12-29 | 78 | 38d | 0d | start no earlier than 2009-06-01 | PINTURA ESMALTE [64.3%]; PINTURA DE TRAFICO [42.9%]; PINTURA WASH PRIMER [58.5%]; SOLVENTE XILOL [10.1%]; OPERARIO [97.5%]; CAPATAZ "B" [19.5%]; PERNOS PARA SUJECION DE GUARDAVIAS [3900%]; TERMINAL DE GUARDAVIAS TIPO 2 [3900%] | 18.72h | 7,017.31 | 07.08.04 | 000000000000173 | 39 | 180.12 | 7024.68 | 20 |
| 81 | 1.7.8.5 | MANTENIMIENTO DE TERMINAL TIPO T2 (PINTADO) | 1d | 2009-10-22 | 2009-10-23 | 79 | 50d | 0d | start no earlier than 2009-06-01 | THINER [1%]; PINTURA ESMALTE EPOXICA BLANCA [4%]; PINTURA DE TRAFICO [4%]; PEON [5.3%]; CAPATAZ "B" [0.5%]; CAMIONETA PICK UP 4x2 84 HP [2.7%]; DETERGENTE [20%]; LIJA [20%] | 0.68h | 27.36 | 07.08.05 | 000000000000174 |  | 13.76 | 27.52 | 75 |
| 82 | 1.7.8.6 | SUMINISTRO E INSTALACION DE POSTES DE GUARDAVIAS | 2d | 2009-11-21 | 2009-11-23 | 69 | 38d | 0d | start no earlier than 2009-06-01 | CEMENTO PORTLAND TIPO I (42.5KG) [5861.6%]; ACEITE PARA MOTOR SAE-30 [67%]; GASOLINA [271.6%]; PETROLEO [226.1%]; FAJA TRANSPORT 18"X50" M.E. 3HP 150 TON/H [1.7%]; OPERARIO [136.9%]; OFICIAL [73.4%]; PEON [502%]; CAPATAZ "B" [26.9%]; CAPATAZ "A" [21.1%]; MEZCLADOR DE CONCRETO 20-35 HP 16 P3 [20.9%]; MOTOBOMBA 7-10 HP 3-4" [1.7%]; VOLQUETE 15 M3 [27.7%]; CAMION CISTERNA 4X2 (AGUA) 2 000GLN [1.7%]; TRACTOR DE ORUGAS DE 190-240 HP [0.7%]; CARGADOR S/LLANTAS 125 - 155 HP 3 YD3. [0.7%]; CARGADOR S/LLANTAS 100-115 HP 2-2.35 YD3 [12.2%]; VIBRADOR DE CONCRETO 4 HP 2.4" [20.9%]; ZARANDA VIBRATORIA 4"x6"x14" M.E. 15 HP [1.7%]; CHANCADORA PRIMARIA SECUNDARIA 5 FAJAS 75 HP 46-70 Ton/h [2.7%]; GRUPO ELECTROGENO 116 HP 75 KW [1.7%]; GRUPO ELECTROGENO 230 HP 150 KW [2.7%]; DERECHO DE EXPLOTACION DE MATERIAL DE CANTERA [1196.2%]; POSTES PARA GUARDAVIA 6"x21/4" E=6.0 mm DE 1.8M [14500%] | 137.18h | 18,861.39 | 07.08.06 | 000000000000175 | 145 | 130.39 | 18906.55 | 80 |
| 83 | 1.7.8.7 | MANTENIMIENTO DE POSTES DE GUARDAVIAS | 11d | 2009-10-23 | 2009-11-03 | 81 | 50d | 0d | start no earlier than 2009-06-01 | THINER [388.5%]; PINTURA ESMALTE [2719.5%]; PEON [188.3%]; CAPATAZ "B" [18.8%]; CAMIONETA PICK UP 4x2 84 HP [94.2%]; DETERGENTE [7770%]; LIJA [7770%] | 265.19h | 7,142.92 | 07.08.07 | 000000000000176 | 777 | 9.27 | 7202.79 | 75 |
| 84 | 1.7.8.8 | SUMINISTRO E INSTALACION DE MODULOS DE GUARDAVIAS | 32d | 2009-11-23 | 2009-12-25 | 82 | 38d | 0d | start no earlier than 2009-06-01 | PINTURA ESMALTE EPOXICO NEGRO [157%]; PINTURA ESMALTE EPOXICA BLANCA [549.5%]; PINTURA ESMALTE ANTICORROSIVA [471%]; DISOLVENTE XILOL [235.5%]; PINTURA DE TRAFICO [157%]; PINTURA WASH PRIMER [471%]; OPERARIO [196.2%]; PEON [196.2%]; CAPATAZ "B" [19.6%]; PERNOS PARA SUJECION DE GUARDAVIAS [36895%]; CAPTAFOROS DE GUARDAVIA [31400%]; GUARDAVIAS TRANSVERSAL [15700%] | 1055.04h | 79,580.11 | 07.08.08 | 000000000000177 | 157 | 509.25 | 79952.25 |  |
| 85 | 1.7.9 | **ALCANTARILLAS Y MUROS** | 31d | 2009-11-03 | 2009-12-04 |  | 50d |  |  |  | 774.79h | 36,627.89 | 07.09 | 000000000000178 |  |  |  |  |
| 86 | 1.7.9.1 | MANTENIMIENTO DE ALCANTARILLAS EXISTENTES | 2d | 2009-11-03 | 2009-11-05 | 83 | 50d | 0d | start no earlier than 2009-06-01 | DILUYENTE DE PINTURA ESMALTE EPOXICA [205.9%]; PINTURA ESMALTE EPOXICO NEGRO [103%]; PINTURA ESMALTE EPOXICA BLANCA [1029.5%]; PINTURA DE TRAFICO [103%]; OFICIAL [73.5%]; PEON [147.1%]; CAPATAZ "B" [14.7%] | 37.66h | 2,971.57 | 07.09.01 | 000000000000179 | 102.95 | 28.98 | 2983.49 | 70 |
| 87 | 1.7.9.2 | MANTENIMIENTO DE MUROS DE BORDE | 29d | 2009-11-05 | 2009-12-04 | 86 | 50d | 0d | start no earlier than 2009-06-01 | DILUYENTE DE PINTURA ESMALTE EPOXICA [2015.7%]; PINTURA ESMALTE EPOXICO NEGRO [1007.8%]; PINTURA ESMALTE EPOXICA BLANCA [10078.3%]; PINTURA DE TRAFICO [2015.7%]; OFICIAL [99.3%]; PEON [198.6%]; CAPATAZ "B" [19.9%] | 737.13h | 33,656.32 | 07.09.02 | 000000000000180 | 1007.83 | 33.63 | 33893.32 | 35 |

| ID | WBS | Task | Type | Duration | Start | Finish | Predecessors | Total slack | Free slack | Constraint | Resources | Work | Cost | Text1 | Text8 | Text3 | Text4 | Text6 | Text2 |
| --- | --- | --- | --- | --- | --- | --- | --- | --- | --- | --- | --- | --- | --- | --- | --- | --- | --- | --- | --- |
| 88 | 1.7.10 | **POSTES KILOMETRICOS** |  | 26d | 2009-12-04 | 2009-12-30 |  | 28d |  |  |  | 161.55h | 4,043.75 | 07.10 | 000000000000181 |  |  |  |  |
| 89 | 1.7.10.1 | POSTE KILOMETRICO |  | 1d | 2009-12-29 | 2009-12-30 | 80 | 38d |  | start no earlier than 2009-06-01 | CEMENTO PORTLAND TIPO I (42.5KG) [396.9%]; ENCOFRADO METALICO [400%]; ACEITE PARA MOTOR SAE-30 [4.4%]; GASOLINA [19.3%]; PETROLEO [15%]; PINTURA ESMALTE EPOXICO NEGRO [7.5%]; PINTURA ESMALTE EPOXICA BLANCA [12.5%]; FAJA TRANSPORT 18"X50" M.E. 3HP 150 TON/H [0.2%]; OPERARIO [113.7%]; OFICIAL [15.4%]; PEON [94.2%]; CAPATAZ "B" [12.2%]; CAPATAZ "A" [2.9%]; MEZCLADOR DE CONCRETO 20-35 HP 16 P3 [2.9%]; MOTOBOMBA 7-10 HP 3-4" [0.2%]; VOLQUETE 15 M3 [1.4%]; CAMION CISTERNA 4X2 (AGUA) 2 000GLN [0.2%]; TRACTOR DE ORUGAS DE 190-240 HP [0.1%]; CARGADOR S/LLANTAS 125 - 155 HP 3 YD3. [0.1%]; CARGADOR S/LLANTAS 100-115 HP 2-2.35 YD3 [0.6%]; VIBRADOR DE CONCRETO 4 HP 2.4" [3.8%]; ZARANDA VIBRATORIA 4"x6"x14" M.E. 15 HP [0.2%]; CHANCADORA PRIMARIA SECUNDARIA 5 FAJAS 75 HP 46-70 Ton/h [0.4%]; GRUPO ELECTROGENO 116 HP 75 KW [0.2%]; GRUPO ELECTROGENO 230 HP 150 KW [0.4%]; ALAMBRE NEGRO RECOCIDO # 8 [162.5%]; ACERO CORRUGADO FY=4200 KG/CM2 GRADO 60 [1706.2%]; DERECHO DE EXPLOTACION DE MATERIAL DE CANTERA [72.5%] | 19.93h | 567.05 | 07.10.01 | 000000000000182 | 114.83 | 574.15 | 10 |  |
| 90 | 1.7.10.2 | MANTENIMIENTO DE POSTES KILOMETRICOS |  | 4d | 2009-12-04 | 2009-12-08 | 87 | 50d |  | start no earlier than 2009-06-01 | THINER [282.5%]; PINTURA ESMALTE EPOXICO NEGRO [169.5%]; PINTURA ESMALTE EPOXICA BLANCA [282.5%]; OPERARIO [94.2%]; OFICIAL [188.3%]; PEON [94.2%]; CAPATAZ "B" [18.8%]; CAMIONETA PICK UP 4x2 84 HP [47.1%]; LIJA [22600%] | 141.62h | 3,476.7 | 07.10.02 | 000000000000183 | 31.16 | 3521.08 | 30 | 113 |
| 91 | 1.8 | **PROTECCION AMBIENTAL** |  | 228d | 2009-06-11 | 2010-01-25 |  | 2d |  |  |  | 591.93h | 173,295.06 | 08 | 000000000000184 |  |  |  |  |
| 92 | 1.8.1 | **MITIGACION AMBIENTAL** |  | 5d | 2009-11-15 | 2009-11-20 |  | 68d |  |  |  |  |  | 08.01 | 000000000000185 |  |  |  |  |
| 93 | 1.8.1.1 | SEÑALIZACION AMBIENTAL |  | 5d | 2009-11-15 | 2009-11-20 | 59 | 68d |  | start no earlier than 2009-06-01 |  |  |  | 08.01.01 | 000000000000186 | 1100 | 13200 |  | 12 |
| 94 | 1.8.2 | **IMPLEMENTACION PMA, EDUCACION Y CAPACITACION AMBIENTAL** |  | 228d | 2009-06-11 | 2010-01-25 |  | 2d |  |  |  |  |  | 08.02 | 000000000000187 |  |  |  |  |
| 95 | 1.8.2.1 | CAPACITACION AL PERSONAL DE OBRA |  | 228d | 2009-06-11 | 2010-01-25 | 4SS | 2d | 0d | start no earlier than 2009-06-01 |  |  |  | 08.02.01 | 000000000000188 | 4500 | 4500 |  |  |
| 96 | 1.8.2.2 | CAPACITACION AL PUBLICO EN GRAL. |  | 3d | 2009-06-11 | 2010-01-25 | 95SS | 2d | 0d | start no earlier than 2009-06-01 |  |  |  | 08.02.01 | 000000000000188 | 4500 | 4500 |  |  |
| 97 | 1.8.2.3 | CAPACITACION A FUNCIONARIOS, PERSONAL PROFESIONAL Y TECNICO |  | 7d | 2009-06-30 | 2010-01-24 | 96SS | 2.5d |  | start no earlier than 2009-06-30 |  |  |  | 08.02.01 | 000000000000188 | 4500 | 4500 |  |  |
| 98 | 1.8.3 | **PROGRAMA DE ABANDONO DE OBRA** |  | 51d | 2009-10-24 | 2009-12-14 |  | 44d |  |  |  | 591.93h | 173,295.06 | 08.04 | 000000000000193 |  |  |  |  |
| 99 | 1.8.3.1 | ACONDICIONAMIENTO DE DEPOSITOS DE MATERIAL EXCEDENTE - DME |  | 45d | 2009-10-24 | 2009-12-08 | 46, 47 | 44d | 0d | start no earlier than 2009-06-01 | PEON [39.6%]; CAPATAZ "B" [4.1%]; TRACTOR DE ORUGAS DE 190-240 HP [39.6%]; DERECHO DE USO DE DME | 300.25h | 154,350.31 | 08.04.01 | 000000000000211 | 4.27 | 226194.75 | 1200 | 52973.01 |
| 100 | 1.8.3.2 | READECUACION AMBIENTAL DE CANTERAS, PLANTAS DE CHANCADO Y DE ASFALTO |  | 3d | 2009-12-08 | 2009-12-11 | 42, 43, 99 | 44d | 0d | start no earlier than 2009-06-01 | GASOLINA [240%]; PEON [324.1%]; CAPATAZ "A" [83.3%]; MOTOBOMBA 7-10 HP 3-4" [74.1%]; CAMION CISTERNA 4X2 (AGUA) 2 000GLN [74.1%]; TRACTOR DE ORUGAS DE 190-240 HP [83.3%] | 153.34h | 10,088.08 | 08.04.02 | 000000000000195 | 2.03 | 10150 | 2000 | 5000 |
| 101 | 1.8.3.3 | READECUACION AMBIENTAL DE CAMPAMENTOS, ALMACENES Y PATIO DE MAQUINAS |  | 3d | 2009-12-11 | 2009-12-14 | 100, 99 | 44d |  | start no earlier than 2009-06-01 | GASOLINA [240%]; PEON [357.4%]; MOTOBOMBA 7-10 HP 3-4" [74.1%]; CAMION CISTERNA 4X2 (AGUA) 2 000GLN [74.1%]; TRACTOR DE ORUGAS DE 190-240 HP [70.8%] | 138.34h | 8,856.66 | 08.04.03 | 000000000000196 | 1.77 | 8850 | 2350 | 5000 |
| 102 | 1.9 | **VARIOS** |  | 65d | 2009-07-25 | 2009-09-28 |  | 0d |  |  |  |  |  |  |  |  |  |  |  |
| 103 | 1.9.1 | TUBERIA DE PVC, SAL 6" PARA DESAGUE |  | 20d | 2009-07-25 | 2009-08-14 | 9 | 0d |  |  |  |  |  |  |  |  |  |  |  |
| 104 | 1.9.2 | NIVELACION DE BUZONES |  | 2d | 2009-09-26 | 2009-09-28 | 15 | 121d |  |  |  |  |  |  |  |  |  |  |  |
| 105 | 1.10 | FIN DE OBRA | milestone | 0d | 2010-01-27 | 2010-01-27 | 70, 3, 5 | 0d |  |  |  |  |  |  |  |  |  |  |  |
